# New Product Launch

How a schedule from MS Project changed from version to version. A marks actual dates.

## Version 1 (saved 2012-12-26, file site_launch.mpp)

| ID | WBS | Task | Duration | Start | Finish | Predecessors | Total float |
| --- | --- | --- | --- | --- | --- | --- | --- |
| 1 | 1 | **New Site Launch Preparation** | 27d | 2013-03-04 | 2013-04-09 |  | 0d |
| 2 | 1.1 | **Phase 1 - Planning** | 8d | 2013-03-04 | 2013-03-13 |  | 0d |
| 3 |  | Identify the launch team | 2d | 2013-03-04 | 2013-03-05 |  | 0d |
| 4 |  | Determine site objectives | 1d | 2013-03-06 | 2013-03-06 | 3 | 0d |
| 5 |  | Identify budget requirements | 1d | 2013-03-07 | 2013-03-07 | 4 | 0d |
| 6 |  | Obtain launch budget approval | 1d | 2013-03-08 | 2013-03-08 | 5 | 0d |
| 7 |  | Define launch goals (launch timing and publicity objectives) | 1d | 2013-03-11 | 2013-03-11 | 6 | 0d |
| 8 |  | Send RFQ | 1d | 2013-03-12 | 2013-03-12 | 7 | 0d |
| 9 |  | Identify technology partners | 1d | 2013-03-13 | 2013-03-13 | 8 | 0d |
| 10 |  | Planning COMPLETE | 0d | 2013-03-13 | 2013-03-13 | 9 | 0d |
| 11 | 1.2 | **Phase 2 - Development** | 18d | 2013-03-14 | 2013-04-08 |  | 0d |
| 12 |  | Define creative brief | 3d | 2013-03-14 | 2013-03-18 | 10 | 0d |
| 13 |  | Set design scope | 1d | 2013-03-19 | 2013-03-19 | 12 | 0d |
| 14 |  | Create design | 4d | 2013-03-20 | 2013-03-25 | 13 | 0d |
| 15 |  | Create code | 2w | 2013-03-26 | 2013-04-08 | 14 | 0d |
| 16 |  | Development Phase COMPLETE | 0d | 2013-04-08 | 2013-04-08 | 15 | 0d |
| 17 | 1.3 | **Phase 3 - Execution** | 1d | 2013-04-09 | 2013-04-09 |  | 0d |
| 18 |  | Upload fles and data | 1d | 2013-04-09 | 2013-04-09 | 16 | 0d |
| 19 |  | Launch Site | 0d | 2013-04-09 | 2013-04-09 | 18 | 0d |

## Version 2 (saved 2015-11-30, file site_launch_filter.mpp)

Last finish 2013-04-09 → 2015-12-29 (+994d). Complete tasks 0 → 6.

Changed:

| ID | Task | Start | Finish | Complete | Total float |
| --- | --- | --- | --- | --- | --- |
| 1 | **New Site Launch Preparation** | 2013-03-04 → 2015-11-23 A (+994d) | 2013-04-09 → 2015-12-29 (+994d) | 0% → 26% |  |
| 2 | **Phase 1 - Planning** | 2013-03-04 → 2015-11-23 A (+994d) | 2013-03-13 → 2015-12-02 (+994d) | 0% → 88% |  |
| 3 | Identify the launch team | 2013-03-04 → 2015-11-23 A (+994d) | 2013-03-05 → 2015-11-24 A (+994d) | 0% → 100% | 0d → none |
| 4 | Determine site objectives | 2013-03-06 → 2015-11-25 A (+994d) | 2013-03-06 → 2015-11-25 A (+994d) | 0% → 100% | 0d → none |
| 5 | Identify budget requirements | 2013-03-07 → 2015-11-26 A (+994d) | 2013-03-07 → 2015-11-26 A (+994d) | 0% → 100% | 0d → none |
| 6 | Obtain launch budget approval | 2013-03-08 → 2015-11-27 A (+994d) | 2013-03-08 → 2015-11-27 A (+994d) | 0% → 100% | 0d → none |
| 7 | Define launch goals (launch timing and publicity objectives) | 2013-03-11 → 2015-11-30 A (+994d) | 2013-03-11 → 2015-11-30 A (+994d) | 0% → 100% | 0d → none |
| 8 | Send RFQ | 2013-03-12 → 2015-12-01 A (+994d) | 2013-03-12 → 2015-12-01 A (+994d) | 0% → 100% | 0d → none |
| 9 | Identify technology partners | 2013-03-13 → 2015-12-02 (+994d) | 2013-03-13 → 2015-12-02 (+994d) |  |  |
| 10 | Planning COMPLETE | 2013-03-13 → 2015-12-02 (+994d) | 2013-03-13 → 2015-12-02 (+994d) |  |  |
| 11 | **Phase 2 - Development** | 2013-03-14 → 2015-12-03 (+994d) | 2013-04-08 → 2015-12-28 (+994d) |  |  |
| 12 | Define creative brief | 2013-03-14 → 2015-12-03 (+994d) | 2013-03-18 → 2015-12-07 (+994d) |  |  |
| 13 | Set design scope | 2013-03-19 → 2015-12-08 (+994d) | 2013-03-19 → 2015-12-08 (+994d) |  |  |
| 14 | Create design | 2013-03-20 → 2015-12-09 (+994d) | 2013-03-25 → 2015-12-14 (+994d) |  |  |
| 15 | Create code | 2013-03-26 → 2015-12-15 (+994d) | 2013-04-08 → 2015-12-28 (+994d) |  |  |
| 16 | Development Phase COMPLETE | 2013-04-08 → 2015-12-28 (+994d) | 2013-04-08 → 2015-12-28 (+994d) |  |  |
| 17 | **Phase 3 - Execution** | 2013-04-09 → 2015-12-29 (+994d) | 2013-04-09 → 2015-12-29 (+994d) |  |  |
| 18 | Upload fles and data | 2013-04-09 → 2015-12-29 (+994d) | 2013-04-09 → 2015-12-29 (+994d) |  |  |
| 19 | Launch Site | 2013-04-09 → 2015-12-29 (+994d) | 2013-04-09 → 2015-12-29 (+994d) |  |  |

## Version 3 (saved 2015-11-30, file site_launch_wbs.mpp)

Last finish stays 2015-12-29. Complete tasks 6 → 0.

Changed:

| ID | Task | Start | Finish | Complete | Total float |
| --- | --- | --- | --- | --- | --- |
| 1 | **New Site Launch Preparation** | 2015-11-23 A → 2015-11-23 |  | 26% → 0% |  |
| 2 | **Phase 1 - Planning** | 2015-11-23 A → 2015-11-23 |  | 88% → 0% |  |
| 3 | Identify the launch team | 2015-11-23 A → 2015-11-23 | 2015-11-24 A → 2015-11-24 | 100% → 0% | none → 0d |
| 4 | Determine site objectives | 2015-11-25 A → 2015-11-25 | 2015-11-25 A → 2015-11-25 | 100% → 0% | none → 0d |
| 5 | Identify budget requirements | 2015-11-26 A → 2015-11-26 | 2015-11-26 A → 2015-11-26 | 100% → 0% | none → 0d |
| 6 | Obtain launch budget approval | 2015-11-27 A → 2015-11-27 | 2015-11-27 A → 2015-11-27 | 100% → 0% | none → 0d |
| 7 | Define launch goals (launch timing and publicity objectives) | 2015-11-30 A → 2015-11-30 | 2015-11-30 A → 2015-11-30 | 100% → 0% | none → 0d |
| 8 | Send RFQ | 2015-12-01 A → 2015-12-01 | 2015-12-01 A → 2015-12-01 | 100% → 0% | none → 0d |
