# catalog_launch

How a schedule from MS Project changed from version to version. A marks actual dates.

## Version 1 (saved 2013-08-16, file catalog_launch.mpp)

| ID | WBS | Task | Duration | Start | Finish | Predecessors | Total float |
| --- | --- | --- | --- | --- | --- | --- | --- |
| 1 | 1 | **New Catalog Launch Preparation** | 24d | 2012-12-03 | 2013-01-03 |  | 0d |
| 2 | 1.1 | **Phase 1 - Planning** | 8d | 2012-12-03 | 2012-12-12 |  | 0d |
| 3 |  | Identify the launch team | 2d | 2012-12-03 | 2012-12-04 |  | 0d |
| 4 |  | Determine catalog objectives | 1d | 2012-12-05 | 2012-12-05 | 3 | 0d |
| 5 |  | Identify budget requirements | 1d | 2012-12-06 | 2012-12-06 | 4 | 0d |
| 6 |  | Obtain launch budget approval | 1d | 2012-12-07 | 2012-12-07 | 5 | 0d |
| 7 |  | Define launch goals (launch timing and publicity objectives) | 1d | 2012-12-10 | 2012-12-10 | 6 | 0d |
| 8 |  | Send RFQ | 1d | 2012-12-11 | 2012-12-11 | 7 | 0d |
| 9 |  | Identify print partners | 1d | 2012-12-12 | 2012-12-12 | 8 | 0d |
| 10 |  | Planning COMPLETE | 0d | 2012-12-12 | 2012-12-12 | 9 | 0d |
| 11 | 1.2 | **Phase 2 - Development** | 10d | 2012-12-13 | 2012-12-26 |  | 0d |
| 12 |  | Define creative brief | 3d | 2012-12-13 | 2012-12-17 | 10 | 0d |
| 13 |  | Set design scope | 1d | 2012-12-18 | 2012-12-18 | 12 | 0d |
| 14 |  | Create images | 2d | 2012-12-19 | 2012-12-20 | 13 | 0d |
| 15 |  | Create catalog | 4d | 2012-12-21 | 2012-12-26 | 14 | 0d |
| 16 |  | Development Phase COMPLETE | 0d | 2012-12-26 | 2012-12-26 | 15 | 0d |
| 17 | 1.3 | **Phase 3 - Execution** | 6d | 2012-12-27 | 2013-01-03 |  | 0d |
| 18 |  | Upload files and data to print house | 1d | 2012-12-27 | 2012-12-27 | 16 | 0d |
| 19 |  | Print Catalog | 5d | 2012-12-28 | 2013-01-03 | 18 | 0d |

## Version 2 (saved 2015-11-30, file catalog_launch_format.mpp)

Last finish 2013-01-03 → 2015-12-24 (+1085d).

Changed:

| ID | Task | Start | Finish |
| --- | --- | --- | --- |
| 1 | **New Catalog Launch Preparation** | 2012-12-03 → 2015-11-23 (+1085d) | 2013-01-03 → 2015-12-24 (+1085d) |
| 2 | **Phase 1 - Planning** | 2012-12-03 → 2015-11-23 (+1085d) | 2012-12-12 → 2015-12-02 (+1085d) |
| 3 | Identify the launch team | 2012-12-03 → 2015-11-23 (+1085d) | 2012-12-04 → 2015-11-24 (+1085d) |
| 4 | Determine catalog objectives | 2012-12-05 → 2015-11-25 (+1085d) | 2012-12-05 → 2015-11-25 (+1085d) |
| 5 | Identify budget requirements | 2012-12-06 → 2015-11-26 (+1085d) | 2012-12-06 → 2015-11-26 (+1085d) |
| 6 | Obtain launch budget approval | 2012-12-07 → 2015-11-27 (+1085d) | 2012-12-07 → 2015-11-27 (+1085d) |
| 7 | Define launch goals (launch timing and publicity objectives) | 2012-12-10 → 2015-11-30 (+1085d) | 2012-12-10 → 2015-11-30 (+1085d) |
| 8 | Send RFQ | 2012-12-11 → 2015-12-01 (+1085d) | 2012-12-11 → 2015-12-01 (+1085d) |
| 9 | Identify print partners | 2012-12-12 → 2015-12-02 (+1085d) | 2012-12-12 → 2015-12-02 (+1085d) |
| 10 | Planning COMPLETE | 2012-12-12 → 2015-12-02 (+1085d) | 2012-12-12 → 2015-12-02 (+1085d) |
| 11 | **Phase 2 - Development** | 2012-12-13 → 2015-12-03 (+1085d) | 2012-12-26 → 2015-12-16 (+1085d) |
| 12 | Define creative brief | 2012-12-13 → 2015-12-03 (+1085d) | 2012-12-17 → 2015-12-07 (+1085d) |
| 13 | Set design scope | 2012-12-18 → 2015-12-08 (+1085d) | 2012-12-18 → 2015-12-08 (+1085d) |
| 14 | Create images | 2012-12-19 → 2015-12-09 (+1085d) | 2012-12-20 → 2015-12-10 (+1085d) |
| 15 | Create catalog | 2012-12-21 → 2015-12-11 (+1085d) | 2012-12-26 → 2015-12-16 (+1085d) |
| 16 | Development Phase COMPLETE | 2012-12-26 → 2015-12-16 (+1085d) | 2012-12-26 → 2015-12-16 (+1085d) |
| 17 | **Phase 3 - Execution** | 2012-12-27 → 2015-12-17 (+1085d) | 2013-01-03 → 2015-12-24 (+1085d) |
| 18 | Upload files and data to print house | 2012-12-27 → 2015-12-17 (+1085d) | 2012-12-27 → 2015-12-17 (+1085d) |
| 19 | Print Catalog | 2012-12-28 → 2015-12-18 (+1085d) | 2013-01-03 → 2015-12-24 (+1085d) |

## Version 3 (saved 2015-11-30, file catalog_launch_filter.mpp)

Last finish stays 2015-12-24. Complete tasks 0 → 8.

Changed:

| ID | Task | Start | Finish | Complete | Total float |
| --- | --- | --- | --- | --- | --- |
| 1 | **New Catalog Launch Preparation** | 2015-11-23 A |  | 0% → 40% |  |
| 2 | **Phase 1 - Planning** | 2015-11-23 A | 2015-12-02 A | 0% → 100% | 0d → none |
| 3 | Identify the launch team | 2015-11-23 A | 2015-11-24 A | 0% → 100% | 0d → none |
| 4 | Determine catalog objectives | 2015-11-25 A | 2015-11-25 A | 0% → 100% | 0d → none |
| 5 | Identify budget requirements | 2015-11-26 A | 2015-11-26 A | 0% → 100% | 0d → none |
| 6 | Obtain launch budget approval | 2015-11-27 A | 2015-11-27 A | 0% → 100% | 0d → none |
| 7 | Define launch goals (launch timing and publicity objectives) | 2015-11-30 A | 2015-11-30 A | 0% → 100% | 0d → none |
| 8 | Send RFQ | 2015-12-01 A | 2015-12-01 A | 0% → 100% | 0d → none |
| 9 | Identify print partners | 2015-12-02 A | 2015-12-02 A | 0% → 100% | 0d → none |
| 10 | Planning COMPLETE | 2015-12-02 A | 2015-12-02 A | 0% → 100% | 0d → none |
| 11 | **Phase 2 - Development** | 2015-12-03 A |  | 0% → 15% |  |
| 12 | Define creative brief | 2015-12-03 A |  | 0% → 50% |  |

## Version 4 (saved 2015-11-30, file catalog_launch_wbs.mpp)

Last finish stays 2015-12-24. Complete tasks 8 → 0.

Changed:

| ID | Task | Start | Finish | Complete | Total float |
| --- | --- | --- | --- | --- | --- |
| 1 | **New Catalog Launch Preparation** | 2015-11-23 A → 2015-11-23 |  | 40% → 0% |  |
| 2 | **Phase 1 - Planning** | 2015-11-23 A → 2015-11-23 | 2015-12-02 A → 2015-12-02 | 100% → 0% | none → 0d |
| 3 | Identify the launch team | 2015-11-23 A → 2015-11-23 | 2015-11-24 A → 2015-11-24 | 100% → 0% | none → 0d |
| 4 | Determine catalog objectives | 2015-11-25 A → 2015-11-25 | 2015-11-25 A → 2015-11-25 | 100% → 0% | none → 0d |
| 5 | Identify budget requirements | 2015-11-26 A → 2015-11-26 | 2015-11-26 A → 2015-11-26 | 100% → 0% | none → 0d |
| 6 | Obtain launch budget approval | 2015-11-27 A → 2015-11-27 | 2015-11-27 A → 2015-11-27 | 100% → 0% | none → 0d |
| 7 | Define launch goals (launch timing and publicity objectives) | 2015-11-30 A → 2015-11-30 | 2015-11-30 A → 2015-11-30 | 100% → 0% | none → 0d |
| 8 | Send RFQ | 2015-12-01 A → 2015-12-01 | 2015-12-01 A → 2015-12-01 | 100% → 0% | none → 0d |
| 9 | Identify print partners | 2015-12-02 A → 2015-12-02 | 2015-12-02 A → 2015-12-02 | 100% → 0% | none → 0d |
| 10 | Planning COMPLETE | 2015-12-02 A → 2015-12-02 | 2015-12-02 A → 2015-12-02 | 100% → 0% | none → 0d |
| 11 | **Phase 2 - Development** | 2015-12-03 A → 2015-12-03 |  | 15% → 0% |  |
| 12 | Define creative brief | 2015-12-03 A → 2015-12-03 |  | 50% → 0% |  |
