# New Product Launch

How a schedule from MS Project changed from version to version. A marks actual dates.

## Version 1 (saved 2015-11-30, file site_launch_gantt.mpp)

| ID | WBS | Task | Duration | Start | Finish | Predecessors | Total float |
| --- | --- | --- | --- | --- | --- | --- | --- |
| 1 | 1 | **New Site Launch Preparation** | 27d | 2015-11-23 | 2015-12-29 |  | 0d |
| 2 | 1.1 | **Phase 1 - Planning** | 8d | 2015-11-23 | 2015-12-02 |  | 0d |
| 3 |  | Identify the launch team | 2d | 2015-11-23 | 2015-11-24 |  | 0d |
| 4 |  | Determine site objectives | 1d | 2015-11-25 | 2015-11-25 | 3 | 0d |
| 5 |  | Identify budget requirements | 1d | 2015-11-26 | 2015-11-26 | 4 | 0d |
| 6 |  | Obtain launch budget approval | 1d | 2015-11-27 | 2015-11-27 | 5 | 0d |
| 7 |  | Define launch goals (launch timing and publicity objectives) | 1d | 2015-11-30 | 2015-11-30 | 6 | 0d |
| 8 |  | Send RFQ | 1d | 2015-12-01 | 2015-12-01 | 7 | 0d |
| 9 |  | Identify technology partners | 1d | 2015-12-02 | 2015-12-02 | 8 | 0d |
| 10 |  | Planning COMPLETE | 0d | 2015-12-02 | 2015-12-02 | 9 | 0d |
| 11 | 1.2 | **Phase 2 - Development** | 18d | 2015-12-03 | 2015-12-28 |  | 0d |
| 12 |  | Define creative brief | 3d | 2015-12-03 | 2015-12-07 | 10 | 0d |
| 13 |  | Set design scope | 1d | 2015-12-08 | 2015-12-08 | 12 | 0d |
| 14 |  | Create design | 4d | 2015-12-09 | 2015-12-14 | 13 | 0d |
| 15 |  | Create code | 2w | 2015-12-15 | 2015-12-28 | 14 | 0d |
| 16 |  | Development Phase COMPLETE | 0d | 2015-12-28 | 2015-12-28 | 15 | 0d |
| 17 | 1.3 | **Phase 3 - Execution** | 1d | 2015-12-29 | 2015-12-29 |  | 0d |
| 18 |  | Upload fles and data | 1d | 2015-12-29 | 2015-12-29 | 16 | 0d |
| 19 |  | Launch Site | 0d | 2015-12-29 | 2015-12-29 | 18 | 0d |

## Version 2 (saved 2015-11-30, file site_launch_filter.mpp)

Last finish stays 2015-12-29. Complete tasks 0 → 6.

Changed:

| ID | Task | Start | Finish | Complete | Total float |
| --- | --- | --- | --- | --- | --- |
| 1 | **New Site Launch Preparation** | 2015-11-23 A |  | 0% → 26% |  |
| 2 | **Phase 1 - Planning** | 2015-11-23 A |  | 0% → 88% |  |
| 3 | Identify the launch team | 2015-11-23 A | 2015-11-24 A | 0% → 100% | 0d → none |
| 4 | Determine site objectives | 2015-11-25 A | 2015-11-25 A | 0% → 100% | 0d → none |
| 5 | Identify budget requirements | 2015-11-26 A | 2015-11-26 A | 0% → 100% | 0d → none |
| 6 | Obtain launch budget approval | 2015-11-27 A | 2015-11-27 A | 0% → 100% | 0d → none |
| 7 | Define launch goals (launch timing and publicity objectives) | 2015-11-30 A | 2015-11-30 A | 0% → 100% | 0d → none |
| 8 | Send RFQ | 2015-12-01 A | 2015-12-01 A | 0% → 100% | 0d → none |

## Version 3 (saved 2015-11-30, file site_launch_wbs.mpp)

Last finish stays 2015-12-29. Complete tasks 6 → 0.

Changed:

| ID | Task | Start | Finish | Complete | Total float |
| --- | --- | --- | --- | --- | --- |
| 1 | **New Site Launch Preparation** | 2015-11-23 A → 2015-11-23 |  | 26% → 0% |  |
| 2 | **Phase 1 - Planning** | 2015-11-23 A → 2015-11-23 |  | 88% → 0% |  |
| 3 | Identify the launch team | 2015-11-23 A → 2015-11-23 | 2015-11-24 A → 2015-11-24 | 100% → 0% | none → 0d |
| 4 | Determine site objectives | 2015-11-25 A → 2015-11-25 | 2015-11-25 A → 2015-11-25 | 100% → 0% | none → 0d |
| 5 | Identify budget requirements | 2015-11-26 A → 2015-11-26 | 2015-11-26 A → 2015-11-26 | 100% → 0% | none → 0d |
| 6 | Obtain launch budget approval | 2015-11-27 A → 2015-11-27 | 2015-11-27 A → 2015-11-27 | 100% → 0% | none → 0d |
| 7 | Define launch goals (launch timing and publicity objectives) | 2015-11-30 A → 2015-11-30 | 2015-11-30 A → 2015-11-30 | 100% → 0% | none → 0d |
| 8 | Send RFQ | 2015-12-01 A → 2015-12-01 | 2015-12-01 A → 2015-12-01 | 100% → 0% | none → 0d |
