# catalog_launch_constraint

How a schedule from MS Project changed from version to version. A marks actual dates.

## Version 1 (saved 2012-12-20, file catalog_launch_constraint.mpp)

| ID | WBS | Task | Duration | Start | Finish | Predecessors | Total float | Constraint |
| --- | --- | --- | --- | --- | --- | --- | --- | --- |
| 1 | 1 | **New Catalog Launch Preparation** | 27d | 2012-12-03 | 2013-01-08 |  | 0d |  |
| 2 | 1.1 | **Phase 1 - Planning** | 8d | 2012-12-03 | 2012-12-12 |  | 5d |  |
| 3 |  | Identify the launch team | 2d | 2012-12-03 | 2012-12-04 |  | 5d |  |
| 4 |  | Determine catalog objectives | 1d | 2012-12-05 | 2012-12-05 | 3 | 5d |  |
| 5 |  | Identify budget requirements | 1d | 2012-12-06 | 2012-12-06 | 4 | 5d |  |
| 6 |  | Obtain launch budget approval | 1d | 2012-12-07 | 2012-12-07 | 5 | 5d |  |
| 7 |  | Define launch goals (launch timing and publicity objectives) | 1d | 2012-12-10 | 2012-12-10 | 6 | 5d |  |
| 8 |  | Send RFQ | 1d | 2012-12-11 | 2012-12-11 | 7 | 5d |  |
| 9 |  | Identify print partners | 1d | 2012-12-12 | 2012-12-12 | 8 | 5d |  |
| 10 |  | Planning COMPLETE | 0d | 2012-12-12 | 2012-12-12 | 9 | 5d |  |
| 11 | 1.2 | **Phase 2 - Development** | 13d | 2012-12-13 | 2012-12-31 |  | 0d |  |
| 12 |  | Define creative brief | 3d | 2012-12-13 | 2012-12-17 | 10 | 5d |  |
| 13 |  | Set design scope | 1d | 2012-12-18 | 2012-12-18 | 12 | 5d |  |
| 14 |  | Create images | 2d | 2012-12-26 | 2012-12-27 | 13 | 0d | must start on 2012-12-26 |
| 15 |  | Create catalog | 4d | 2012-12-26 | 2012-12-31 | 14SS | 0d |  |
| 16 |  | Development Phase COMPLETE | 0d | 2012-12-31 | 2012-12-31 | 15 | 0d |  |
| 17 | 1.3 | **Phase 3 - Execution** | 6d | 2013-01-01 | 2013-01-08 |  | 0d |  |
| 18 |  | Upload fles and data to print house | 1d | 2013-01-01 | 2013-01-01 | 16 | 0d |  |
| 19 |  | Print Catalog | 5d | 2013-01-02 | 2013-01-08 | 18 | 0d |  |

## Version 2 (saved 2012-12-21, file catalog_launch_split.mpp)

Last finish 2013-01-08 → 2013-01-14 (+6d). Complete tasks 0 → 11.

Changed:

| ID | Task | Start | Finish | Duration | Complete | Total float |
| --- | --- | --- | --- | --- | --- | --- |
| 1 | **New Catalog Launch Preparation** | 2012-12-03 A | 2013-01-08 → 2013-01-14 (+6d) | 27d → 31d | 0% → 67% |  |
| 2 | **Phase 1 - Planning** | 2012-12-03 A | 2012-12-12 A |  | 0% → 100% | 5d → none |
| 3 | Identify the launch team | 2012-12-03 A | 2012-12-04 A |  | 0% → 100% | 5d → none |
| 4 | Determine catalog objectives | 2012-12-05 A | 2012-12-05 A |  | 0% → 100% | 5d → none |
| 5 | Identify budget requirements | 2012-12-06 A | 2012-12-06 A |  | 0% → 100% | 5d → none |
| 6 | Obtain launch budget approval | 2012-12-07 A | 2012-12-07 A |  | 0% → 100% | 5d → none |
| 7 | Define launch goals (launch timing and publicity objectives) | 2012-12-10 A | 2012-12-10 A |  | 0% → 100% | 5d → none |
| 8 | Send RFQ | 2012-12-11 A | 2012-12-11 A |  | 0% → 100% | 5d → none |
| 9 | Identify print partners | 2012-12-12 A | 2012-12-12 A |  | 0% → 100% | 5d → none |
| 10 | Planning COMPLETE | 2012-12-12 A | 2012-12-12 A |  | 0% → 100% | 5d → none |
| 11 | **Phase 2 - Development** | 2012-12-13 A | 2012-12-31 → 2013-01-04 (+4d) | 13d → 17d | 0% → 80% |  |
| 12 | Define creative brief | 2012-12-13 A | 2012-12-17 A |  | 0% → 100% | 5d → none |
| 13 | Set design scope | 2012-12-18 A | 2012-12-18 A |  | 0% → 100% | 5d → none |
| 14 | Create images | 2012-12-26 A | 2012-12-27 A |  | 0% → 100% | 0d → none |
| 15 | Create catalog | 2012-12-26 A | 2012-12-31 → 2013-01-04 (+4d) |  | 0% → 50% |  |
| 16 | Development Phase COMPLETE | 2012-12-31 → 2013-01-04 (+4d) | 2012-12-31 → 2013-01-04 (+4d) |  |  |  |
| 17 | **Phase 3 - Execution** | 2013-01-01 → 2013-01-07 (+6d) | 2013-01-08 → 2013-01-14 (+6d) |  |  |  |
| 18 | Upload fles and data to print house | 2013-01-01 → 2013-01-07 (+6d) | 2013-01-01 → 2013-01-07 (+6d) |  |  |  |
| 19 | Print Catalog | 2013-01-02 → 2013-01-08 (+6d) | 2013-01-08 → 2013-01-14 (+6d) |  |  |  |

## Version 3 (saved 2012-12-21, file catalog_launch_delay.mpp)

Last finish 2013-01-14 → 2013-01-16 (+2d). Complete tasks 11 → 13.

Changed:

| ID | Task | Start | Finish | Duration | Complete | Total float | Other |
| --- | --- | --- | --- | --- | --- | --- | --- |
| 1 | **New Catalog Launch Preparation** |  | 2013-01-14 → 2013-01-16 (+2d) | 31d → 33d | 67% → 75% |  |  |
| 11 | **Phase 2 - Development** |  | 2013-01-04 A |  | 80% → 100% | 0d → none |  |
| 15 | Create catalog |  | 2013-01-04 A |  | 50% → 100% | 0d → none |  |
| 16 | Development Phase COMPLETE | 2013-01-04 A | 2013-01-04 A |  | 0% → 100% | 0d → none |  |
| 17 | **Phase 3 - Execution** | 2013-01-07 → 2013-01-09 (+2d) | 2013-01-14 → 2013-01-16 (+2d) |  |  |  |  |
| 18 | Upload fles and data to print house | 2013-01-07 → 2013-01-09 (+2d) | 2013-01-07 → 2013-01-09 (+2d) |  |  |  | constraint none → start no earlier than 2013-01-09 |
| 19 | Print Catalog | 2013-01-08 → 2013-01-10 (+2d) | 2013-01-14 → 2013-01-16 (+2d) |  |  |  |  |

## Version 4 (saved 2012-12-21, file catalog_launch_lag_lead.mpp)

Last finish 2013-01-16 → 2013-01-09 (-7d). Complete tasks 13 → 0.

Changed:

| ID | Task | Start | Finish | Duration | Complete | Total float | Predecessors | Other |
| --- | --- | --- | --- | --- | --- | --- | --- | --- |
| 1 | **New Catalog Launch Preparation** | 2012-12-03 A → 2012-12-03 | 2013-01-16 → 2013-01-09 (-7d) | 33d → 28d | 75% → 0% |  |  |  |
| 2 | **Phase 1 - Planning** | 2012-12-03 A → 2012-12-03 | 2012-12-12 A → 2012-12-19 (+7d) | 8d → 13d | 100% → 0% | none → 0d |  |  |
| 3 | Identify the launch team | 2012-12-03 A → 2012-12-03 | 2012-12-04 A → 2012-12-04 |  | 100% → 0% | none → 0d |  |  |
| 4 | Determine catalog objectives | 2012-12-05 A → 2012-12-05 | 2012-12-05 A → 2012-12-05 |  | 100% → 0% | none → 0d |  |  |
| 5 | Identify budget requirements | 2012-12-06 A → 2012-12-06 | 2012-12-06 A → 2012-12-06 |  | 100% → 0% | none → 0d |  |  |
| 6 | Obtain launch budget approval | 2012-12-07 A → 2012-12-07 | 2012-12-07 A → 2012-12-07 |  | 100% → 0% | none → 0d |  |  |
| 7 | Define launch goals (launch timing and publicity objectives) | 2012-12-10 A → 2012-12-10 | 2012-12-10 A → 2012-12-10 |  | 100% → 0% | none → 0d |  |  |
| 8 | Send RFQ | 2012-12-11 A → 2012-12-18 (+7d) | 2012-12-11 A → 2012-12-18 (+7d) |  | 100% → 0% | none → 0d | 7 → 7FS+1w |  |
| 9 | Identify print partners | 2012-12-12 A → 2012-12-19 (+7d) | 2012-12-12 A → 2012-12-19 (+7d) |  | 100% → 0% | none → 0d |  |  |
| 10 | Planning COMPLETE | 2012-12-12 A → 2012-12-19 (+7d) | 2012-12-12 A → 2012-12-19 (+7d) |  | 100% → 0% | none → 0d |  |  |
| 11 | **Phase 2 - Development** | 2012-12-13 A → 2012-12-20 (+7d) | 2013-01-04 A → 2013-01-01 (-3d) | 17d → 9d | 100% → 0% | none → 0d |  |  |
| 12 | Define creative brief | 2012-12-13 A → 2012-12-20 (+7d) | 2012-12-17 A → 2012-12-24 (+7d) |  | 100% → 0% | none → 0d |  |  |
| 13 | Set design scope | 2012-12-18 A → 2012-12-24 (+6d) | 2012-12-18 A → 2012-12-24 (+6d) |  | 100% → 0% | none → 0d | 12 → 12FS-1d |  |
| 14 | Create images | 2012-12-26 A → 2012-12-25 (-1d) | 2012-12-27 A → 2012-12-26 (-1d) |  | 100% → 0% | none → 0d |  | constraint must start on 2012-12-26 → none |
| 15 | Create catalog | 2012-12-26 A → 2012-12-27 (+1d) | 2013-01-04 A → 2013-01-01 (-3d) |  | 100% → 0% | none → 0d | 14SS → 14 |  |
| 16 | Development Phase COMPLETE | 2013-01-04 A → 2013-01-01 (-3d) | 2013-01-04 A → 2013-01-01 (-3d) |  | 100% → 0% | none → 0d |  |  |
| 17 | **Phase 3 - Execution** | 2013-01-09 → 2013-01-02 (-7d) | 2013-01-16 → 2013-01-09 (-7d) |  |  |  |  |  |
| 18 | Upload fles and data to print house | 2013-01-09 → 2013-01-02 (-7d) | 2013-01-09 → 2013-01-02 (-7d) |  |  |  |  | constraint start no earlier than 2013-01-09 → none |
| 19 | Print Catalog | 2013-01-10 → 2013-01-03 (-7d) | 2013-01-16 → 2013-01-09 (-7d) |  |  |  |  |  |

## Version 5 (saved 2012-12-21, file catalog_launch_team.mpp)

Last finish 2013-01-09 → 2013-01-03 (-6d).

Changed:

| ID | Task | Start | Finish | Duration | Predecessors |
| --- | --- | --- | --- | --- | --- |
| 1 | **New Catalog Launch Preparation** |  | 2013-01-09 → 2013-01-03 (-6d) | 28d → 24d |  |
| 2 | **Phase 1 - Planning** |  | 2012-12-19 → 2012-12-12 (-7d) | 13d → 8d |  |
| 8 | Send RFQ | 2012-12-18 → 2012-12-11 (-7d) | 2012-12-18 → 2012-12-11 (-7d) |  | 7FS+1w → 7 |
| 9 | Identify print partners | 2012-12-19 → 2012-12-12 (-7d) | 2012-12-19 → 2012-12-12 (-7d) |  |  |
| 10 | Planning COMPLETE | 2012-12-19 → 2012-12-12 (-7d) | 2012-12-19 → 2012-12-12 (-7d) |  |  |
| 11 | **Phase 2 - Development** | 2012-12-20 → 2012-12-13 (-7d) | 2013-01-01 → 2012-12-26 (-6d) | 9d → 10d |  |
| 12 | Define creative brief | 2012-12-20 → 2012-12-13 (-7d) | 2012-12-24 → 2012-12-17 (-7d) |  |  |
| 13 | Set design scope | 2012-12-24 → 2012-12-18 (-6d) | 2012-12-24 → 2012-12-18 (-6d) |  | 12FS-1d → 12 |
| 14 | Create images | 2012-12-25 → 2012-12-19 (-6d) | 2012-12-26 → 2012-12-20 (-6d) |  |  |
| 15 | Create catalog | 2012-12-27 → 2012-12-21 (-6d) | 2013-01-01 → 2012-12-26 (-6d) |  |  |
| 16 | Development Phase COMPLETE | 2013-01-01 → 2012-12-26 (-6d) | 2013-01-01 → 2012-12-26 (-6d) |  |  |
| 17 | **Phase 3 - Execution** | 2013-01-02 → 2012-12-27 (-6d) | 2013-01-09 → 2013-01-03 (-6d) |  |  |
| 18 | Upload fles and data to print house | 2013-01-02 → 2012-12-27 (-6d) | 2013-01-02 → 2012-12-27 (-6d) |  |  |
| 19 | Print Catalog | 2013-01-03 → 2012-12-28 (-6d) | 2013-01-09 → 2013-01-03 (-6d) |  |  |

## Version 6 (saved 2012-12-21, file catalog_launch_needs_res.mpp)

Last finish stays 2013-01-03.

Changed:

| ID | Task | Other |
| --- | --- | --- |
| 3 | Identify the launch team | resources Manager → none |
| 4 | Determine catalog objectives | resources Client; Manager → none |
| 5 | Identify budget requirements | resources Client; Manager → none |
| 6 | Obtain launch budget approval | resources Client; Manager → none |
| 7 | Define launch goals (launch timing and publicity objectives) | resources Client; Manager → none |
| 8 | Send RFQ | resources Manager → none |
| 9 | Identify print partners | resources Manager → none |
| 12 | Define creative brief | resources Client; Manager → none |
| 13 | Set design scope | resources Manager → none |
| 14 | Create images | resources Photographer → none |
| 15 | Create catalog | resources Designer → none |
| 18 | Upload fles and data to print house | resources Manager → none |
| 19 | Print Catalog | resources Printer → none |

## Version 7 (saved 2012-12-21, file catalog_launch_pay_rates.mpp)

Last finish stays 2013-01-03.

Changed:

| ID | Task | Other |
| --- | --- | --- |
| 3 | Identify the launch team | resources none → Manager |
| 4 | Determine catalog objectives | resources none → Client; Manager |
| 5 | Identify budget requirements | resources none → Client; Manager |
| 6 | Obtain launch budget approval | resources none → Client; Manager |
| 7 | Define launch goals (launch timing and publicity objectives) | resources none → Client; Manager |
| 8 | Send RFQ | resources none → Manager |
| 9 | Identify print partners | resources none → Manager |
| 12 | Define creative brief | resources none → Client; Manager |
| 13 | Set design scope | resources none → Manager |
| 14 | Create images | resources none → Photographer |
| 15 | Create catalog | resources none → Designer |
| 18 | Upload fles and data to print house | resources none → Manager |
| 19 | Print Catalog | resources none → Printer |

## Version 8 (saved 2015-11-30, file site_launch_team_done.mpp)

Last finish 2013-01-03 → 2016-02-10 (+1133d).

Changed:

| ID | Task | Start | Finish | Duration | Total float | Predecessors | Other |
| --- | --- | --- | --- | --- | --- | --- | --- |
| 1 | **New Catalog Launch Preparation** | 2012-12-03 → 2015-11-23 (+1085d) | 2013-01-03 → 2016-02-10 (+1133d) | 24d → 58d |  |  |  |
| 2 | **Phase 1 - Planning** | 2012-12-03 → 2015-11-23 (+1085d) | 2012-12-12 → 2015-12-09 (+1092d) | 8d → 13d | 0d → 12d |  |  |
| 3 | Identify the launch team | 2012-12-03 → 2015-11-23 (+1085d) | 2012-12-04 → 2015-11-24 (+1085d) |  | 0d → 12d |  |  |
| 4 | Determine catalog objectives | 2012-12-05 → 2015-11-25 (+1085d) | 2012-12-05 → 2015-11-25 (+1085d) |  | 0d → 12d |  |  |
| 5 | Identify budget requirements | 2012-12-06 → 2015-11-26 (+1085d) | 2012-12-06 → 2015-11-26 (+1085d) |  | 0d → 12d |  |  |
| 6 | Obtain launch budget approval | 2012-12-07 → 2015-11-27 (+1085d) | 2012-12-07 → 2015-11-27 (+1085d) |  | 0d → 12d |  |  |
| 7 | Define launch goals (launch timing and publicity objectives) | 2012-12-10 → 2015-11-30 (+1085d) | 2012-12-10 → 2015-11-30 (+1085d) |  | 0d → 12d |  |  |
| 8 | Send RFQ | 2012-12-11 → 2015-12-08 (+1092d) | 2012-12-11 → 2015-12-08 (+1092d) |  | 0d → 12d | 7 → 7FS+1w |  |
| 9 | Identify print partners | 2012-12-12 → 2015-12-09 (+1092d) | 2012-12-12 → 2015-12-09 (+1092d) |  | 0d → 12d |  |  |
| 10 | Planning COMPLETE | 2012-12-12 → 2015-12-09 (+1092d) | 2012-12-12 → 2015-12-09 (+1092d) |  | 0d → 12d |  |  |
| 11 | **Phase 2 - Development** | 2012-12-13 → 2015-12-10 (+1092d) | 2012-12-26 → 2016-01-19 (+1119d) | 10d → 29d | 0d → 10d |  |  |
| 12 | Define creative brief | 2012-12-13 → 2015-12-10 (+1092d) | 2012-12-17 → 2015-12-14 (+1092d) |  | 0d → 12d |  |  |
| 13 | Set design scope | 2012-12-18 → 2015-12-14 (+1091d) | 2012-12-18 → 2015-12-14 (+1091d) |  | 0d → 12d | 12 → 12FS-1d |  |
| 14 | Create images | 2012-12-19 → 2015-12-31 (+1107d) | 2012-12-20 → 2016-01-01 (+1107d) |  |  |  | constraint none → must start on 2015-12-31 |
| 15 | Create catalog | 2012-12-21 → 2015-12-31 (+1105d) | 2012-12-26 → 2016-01-19 (+1119d) |  | 0d → 10d | 14 → 14SS |  |
| 16 | Development Phase COMPLETE | 2012-12-26 → 2016-01-19 (+1119d) | 2012-12-26 → 2016-01-19 (+1119d) |  | 0d → 10d |  |  |
| 17 | **Phase 3 - Execution** | 2012-12-27 → 2016-02-03 (+1133d) | 2013-01-03 → 2016-02-10 (+1133d) |  |  |  |  |
| 18 | Upload files and data to print house | 2012-12-27 → 2016-02-03 (+1133d) | 2012-12-27 → 2016-02-03 (+1133d) |  |  |  | was named Upload fles and data to print house; constraint none → start no earlier than 2016-02-03 |
| 19 | Print Catalog | 2012-12-28 → 2016-02-04 (+1133d) | 2013-01-03 → 2016-02-10 (+1133d) |  |  |  |  |

## Version 9 (saved 2015-11-30, file catalog_launch_needs_resDONE.mpp)

Last finish 2016-02-10 → 2015-12-24 (-48d).

Changed:

| ID | Task | Start | Finish | Duration | Total float | Predecessors | Other |
| --- | --- | --- | --- | --- | --- | --- | --- |
| 1 | **New Catalog Launch Preparation** |  | 2016-02-10 → 2015-12-24 (-48d) | 58d → 24d |  |  |  |
| 2 | **Phase 1 - Planning** |  | 2015-12-09 → 2015-12-02 (-7d) | 13d → 8d | 12d → 0d |  |  |
| 3 | Identify the launch team |  |  |  | 12d → 0d |  | resources Manager → none |
| 4 | Determine catalog objectives |  |  |  | 12d → 0d |  | resources Client; Manager → none |
| 5 | Identify budget requirements |  |  |  | 12d → 0d |  | resources Client; Manager → none |
| 6 | Obtain launch budget approval |  |  |  | 12d → 0d |  | resources Client; Manager → none |
| 7 | Define launch goals (launch timing and publicity objectives) |  |  |  | 12d → 0d |  | resources Client; Manager → none |
| 8 | Send RFQ | 2015-12-08 → 2015-12-01 (-7d) | 2015-12-08 → 2015-12-01 (-7d) |  | 12d → 0d | 7FS+1w → 7 | resources Manager → none |
| 9 | Identify print partners | 2015-12-09 → 2015-12-02 (-7d) | 2015-12-09 → 2015-12-02 (-7d) |  | 12d → 0d |  | resources Manager → none |
| 10 | Planning COMPLETE | 2015-12-09 → 2015-12-02 (-7d) | 2015-12-09 → 2015-12-02 (-7d) |  | 12d → 0d |  |  |
| 11 | **Phase 2 - Development** | 2015-12-10 → 2015-12-03 (-7d) | 2016-01-19 → 2015-12-16 (-34d) | 29d → 10d | 10d → 0d |  |  |
| 12 | Define creative brief | 2015-12-10 → 2015-12-03 (-7d) | 2015-12-14 → 2015-12-07 (-7d) |  | 12d → 0d |  | resources Client; Manager → none |
| 13 | Set design scope | 2015-12-14 → 2015-12-08 (-6d) | 2015-12-14 → 2015-12-08 (-6d) |  | 12d → 0d | 12FS-1d → 12 | resources Manager → none |
| 14 | Create images | 2015-12-31 → 2015-12-09 (-22d) | 2016-01-01 → 2015-12-10 (-22d) |  |  |  | constraint must start on 2015-12-31 → none; resources Photographer → none |
| 15 | Create catalog | 2015-12-31 → 2015-12-11 (-20d) | 2016-01-19 → 2015-12-16 (-34d) |  | 10d → 0d | 14SS → 14 | resources Designer → none |
| 16 | Development Phase COMPLETE | 2016-01-19 → 2015-12-16 (-34d) | 2016-01-19 → 2015-12-16 (-34d) |  | 10d → 0d |  |  |
| 17 | **Phase 3 - Execution** | 2016-02-03 → 2015-12-17 (-48d) | 2016-02-10 → 2015-12-24 (-48d) |  |  |  |  |
| 18 | Upload fles and data to print house | 2016-02-03 → 2015-12-17 (-48d) | 2016-02-03 → 2015-12-17 (-48d) |  |  |  | was named Upload files and data to print house; constraint start no earlier than 2016-02-03 → none; resources Manager → none |
| 19 | Print Catalog | 2016-02-04 → 2015-12-18 (-48d) | 2016-02-10 → 2015-12-24 (-48d) |  |  |  | resources Printer → none |
